# Proyecto_CSJ_v3 (Linea Base Externa - Ajuste Administrativo con Materialización de Riesgo Suspensión)

Schedule from MS Project, 2013-08-26 to 2016-03-14, costs in $.

## Calendars

- Standard: Mon-Fri 09:00-13:00, 15:00-19:00; Sat-Sun off.

## Resources

| Resource | Rate |
| --- | --- |
| Gerente General | 51136.4 |
| Gerente Administrativa | 45454.6 |
| Gerente de Proyectos | 45454.6 |
| Gerente Comercial | 34090.9 |
| Revisor Fiscal | 25568.2 |
| Abogado | 22727.3 |
| Director de Presupuestos y Diseño | 25568.2 |
| Director de Obra | 34090.9 |
| Asesor Técnico | 28409.1 |
| Director de Marketing | 21590.9 |
| Jefe de Compras | 18750 |
| Contador | 14772.7 |
| Profesional HSEQ | 17045.5 |
| Jefe de Personal | 13068.2 |
| Ingeniero de Presupuestos | 18181.8 |
| Residente de Obra | 18750 |
| Servicios Generales | 3977.27 |
| Ingeniero de Diseño | 25000 |
| Encargado de Obra | 13636.4 |
| Asistente Comercial | 13636.4 |
| Asistente de Presupuestos y Diseño | 13636.4 |
| Asistente Contable | 7954.55 |
| Jefe de Almacen | 12500 |
| Director de Publicidad | 18750 |
| Residente de Siso | 26704.5 |
| Tecnico de Campo 27 | 11931.8 |
| Tecnico de Campo 28 | 11931.8 |
| Tecnico de Campo 29 | 11931.8 |
| Tecnico de Campo 30 | 11931.8 |
| Tecnico de Campo 31 | 11931.8 |
| Tecnico de Campo 32 | 11931.8 |
| Tecnico de Campo 33 | 11931.8 |
| Tecnico de Campo 34 | 11931.8 |
| Tecnico de Campo 35 | 11931.8 |
| Tecnico de Campo 36 | 11931.8 |
| Tecnico de Campo 37 | 11931.8 |
| Tecnico de Campo 38 | 11931.8 |
| Tecnico de Campo 39 | 11931.8 |
| Tecnico de Campo 40 | 11931.8 |
| Tecnico de Campo 1 | 11931.8 |
| Tecnico de Campo 2 | 11931.8 |
| Tecnico de Campo 3 | 11931.8 |
| Tecnico de Campo 4 | 11931.8 |
| Tecnico de Campo 5 | 11931.8 |
| Tecnico de Campo 15 | 11931.8 |
| Tecnico de Campo 7 | 11931.8 |
| Tecnico de Campo 6 | 11931.8 |
| Tecnico de Campo 16 | 11931.8 |
| Tecnico de Campo 22 | 11931.8 |
| Tecnico de Campo 23 | 11931.8 |
| Tecnico de Campo 24 | 11931.8 |
| Tecnico de Campo 25 | 11931.8 |
| Tecnico de Campo 26 | 11931.8 |
| Tecnico de Campo 17 | 11931.8 |
| Tecnico de Campo 18 | 11931.8 |
| Tecnico de Campo 19 | 11931.8 |
| Tecnico de Campo 20 | 11931.8 |
| Tecnico de Campo 21 | 11931.8 |
| Tecnico de Campo 8 | 11931.8 |
| Tecnico de Campo 9 | 11931.8 |
| Tecnico de Campo 10 | 11931.8 |
| Tecnico de Campo 11 | 11931.8 |
| Tecnico de Campo 12 | 11931.8 |
| Tecnico de Campo 13 | 11931.8 |
| Tecnico de Campo 14 | 11931.8 |
| Ayudante 1 | 6818.18 |
| Ayudante 2 | 6818.18 |
| Ayudante 3 | 6818.18 |
| Ayudante 4 | 6818.18 |
| Ayudante 5 | 6818.18 |
| Ayudante 6 | 6818.18 |
| Ayudante 7 | 6818.18 |
| Ayudante 8 | 6818.18 |
| Ayudante 9 | 6818.18 |
| Ayudante 10 | 6818.18 |
| Ayudante 11 | 6818.18 |
| Ayudante 12 | 6818.18 |
| Ayudante 13 | 6818.18 |
| Ayudante 14 | 6818.18 |
| Ayudante 15 | 6818.18 |
| Ayudante 16 | 6818.18 |
| Ayudante 17 | 6818.18 |
| Ayudante 18 | 6818.18 |
| Ayudante 19 | 6818.18 |
| Ayudante 20 | 6818.18 |
| Ayudante 21 | 6818.18 |
| Ayudante 22 | 6818.18 |
| Ayudante 23 | 6818.18 |
| Ayudante 24 | 6818.18 |
| Ayudante 25 | 6818.18 |
| Ayudante 26 | 6818.18 |
| Ayudante 27 | 6818.18 |
| Ayudante 28 | 6818.18 |
| Ayudante 29 | 6818.18 |
| Ayudante 30 | 6818.18 |
| Ayudante 31 | 6818.18 |
| Ayudante 32 | 6818.18 |
| Ayudante 33 | 6818.18 |
| Ayudante 34 | 6818.18 |
| Ayudante 35 | 6818.18 |
| Ayudante 36 | 6818.18 |
| Ayudante 37 | 6818.18 |
| Ayudante 38 | 6818.18 |
| Ayudante 39 | 6818.18 |
| Ayudante 40 | 6818.18 |
| IngenieroTecnico | 44886.4 |
| Dibujante Tecnico 1 | 18181.8 |
| Dibujante Tecnico 2 | 18181.8 |
| Inspector SISO 1 | 13068.2 |
| Inspector SISO 5 | 13068.2 |
| Inspector SISO 4 | 13068.2 |
| Inspector SISO 3 | 13068.2 |
| Inspector SISO 2 | 13068.2 |
| Inspector SISO 6 | 13068.2 |

## Schedule

| ID | WBS | Task | Type | Duration | Start | Finish | Predecessors | Total slack | Free slack | Constraint | Resources | Work | Cost |
| --- | --- | --- | --- | --- | --- | --- | --- | --- | --- | --- | --- | --- | --- |
| 1 | 1 | **REDES SECAS NUEVA SEDE DEL CONSEJO SUPERIOR DE LA JUDICATURA** |  | 666d | 2013-08-26 | 2016-03-14 |  | 0d |  |  |  | 193964h | 10,838,870,718.69 |
| 2 | 1.1 | **ADMINISTRACION DEL PROYECTO** |  | 666d | 2013-08-26 | 2016-03-14 |  | 0d |  |  |  | 60520h | 1,360,104,976.49 |
| 3 | 1.1.1 | Gestion financera |  | 445d | 2013-08-26 | 2016-03-14 |  | 0d |  |  | Asistente Contable; Contador; Gerente Administrativa; Gerente de Proyectos; Gerente General; Revisor Fiscal; Director de Obra | 24920h | 398,074,256.23 |
| 4 | 1.1.2 | Gestión Administrativa |  | 445d | 2013-08-26 | 2016-03-11 |  | 0d |  | start no earlier than 2013-08-26 |  |  | 511,569,356.62 |
| 5 | 1.1.3 | Gestion de Calidad |  | 445d | 2013-08-26 | 2016-03-14 |  | 0d |  |  | Profesional HSEQ; Inspector SISO 1; Inspector SISO 2; Inspector SISO 3; Inspector SISO 4; Inspector SISO 5; Residente de Siso | 24920h | 330,109,090.91 |
| 6 | 1.1.4 | Gestion de Recursos Humanos |  | 445d | 2013-08-26 | 2016-03-14 |  | 0d |  |  | Abogado; Jefe de Personal; Servicios Generales | 10680h | 120,352,272.73 |
| 7 | 1.2 | **ANALISIS DE INFORMACIÓN DE DISEÑO Y PLANIMETRÍA** |  | 30d | 2013-08-26 | 2013-10-04 |  | 0d | 75d |  |  | 1760h | 26,427,272.75 |
| 8 | 1.2.1 | **RECOPILACIÓN INFORMACIÓN PRELIMINAR** |  | 20d | 2013-08-26 | 2013-09-20 |  | 0d | 75d |  |  | 800h | 11,011,363.64 |
| 9 | 1.2.1.1 | Reconocimiento del edificio verificacion de rutas y espacios |  | 5d | 2013-08-26 | 2013-08-30 |  | 0d |  | start no earlier than 2013-08-26 | Encargado de Obra; Residente de Obra | 80h | 1,101,136.37 |
| 10 | 1.2.1.2 | Verificación de planos y diseño sistema electrico |  | 15d | 2013-09-02 | 2013-09-20 | 9 | 0d |  | start no earlier than 2013-08-26 | Residente de Obra; Encargado de Obra | 240h | 3,303,409.09 |
| 11 | 1.2.1.3 | Verificación de planos y diseño sistema telecomunicaciones |  | 15d | 2013-09-02 | 2013-09-20 | 9 | 0d |  | start no earlier than 2013-08-26 | Residente de Obra; Encargado de Obra | 240h | 3,303,409.09 |
| 12 | 1.2.1.4 | Verificación de planos y diseño sistema de seguridad |  | 15d | 2013-09-02 | 2013-09-20 | 9 | 0d |  | start no earlier than 2013-08-26 | Residente de Obra; Encargado de Obra | 240h | 3,303,409.09 |
| 13 | 1.2.2 | **PROCESAMIENTO DE INFORMACION Y REVISION INICIAL** |  | 10d | 2013-09-23 | 2013-10-04 |  | 0d | 75d |  |  | 960h | 15,415,909.11 |
| 14 | 1.2.2.1 | Ajustes a los recursos previstos |  | 10d | 2013-09-23 | 2013-10-04 | 10, 11, 12 | 0d | 613d | start no earlier than 2013-09-23 | Encargado de Obra; Residente de Obra; Ingeniero de Diseño; Ingeniero de Presupuestos | 320h | 5,138,636.37 |
| 15 | 1.2.2.2 | Ajustes a los tiempos previstos |  | 10d | 2013-09-23 | 2013-10-04 | 10, 11, 12 | 0d | 613d | start no earlier than 2013-09-23 | Encargado de Obra; Residente de Obra; Ingeniero de Diseño; Ingeniero de Presupuestos | 320h | 5,138,636.37 |
| 16 | 1.2.2.3 | Ajustes a los costos previstos |  | 10d | 2013-09-23 | 2013-10-04 | 10, 11, 12 | 0d |  | start no earlier than 2013-09-23 | Encargado de Obra; Residente de Obra; Ingeniero de Diseño; Ingeniero de Presupuestos | 320h | 5,138,636.37 |
| 17 | 1.3 | **ADQUISICIÓN DE MATERIALES** |  | 561d | 2013-10-07 | 2015-11-30 |  | 0d | 75d |  |  | 16320h | 216,750,000 |
| 18 | 1.3.1 | Suministro de Elementos del Sistema Eléctrico |  | 340d | 2013-10-07 | 2015-11-30 | 16 | 0d | 75d | start no earlier than 2013-10-07 | Jefe de Compras; Jefe de Almacen | 5440h | 72,250,000 |
| 19 | 1.3.2 | Suministro de Elementos del Sistema de Telecomunicaciones |  | 340d | 2013-10-07 | 2015-11-30 | 16 | 0d | 75d | start no earlier than 2013-10-07 | Jefe de Compras; Jefe de Almacen | 5440h | 72,250,000 |
| 20 | 1.3.3 | Suministro de Elementos del Sistema de Seguridad |  | 340d | 2013-10-07 | 2015-11-30 | 16 | 0d | 75d | start no earlier than 2013-10-07 | Jefe de Compras; Jefe de Almacen | 5440h | 72,250,000 |
| 21 | 1.4 | **INGENIERÍA DE IMPLEMENTACIÓN INTERDISCIPLINARIA** |  | 261d | 2013-08-26 | 2014-08-25 |  | 0d | 405d |  |  | 94891.8h | 7,237,365,856.26 |
| 22 | 1.4.1 | **SISTEMA ELECTRICO** |  | 254d | 2013-08-26 | 2014-08-14 |  | 0d | 412d |  |  | 46396h | 3,387,813,859.09 |
| 23 | 1.4.1.1 | **CANALIZACION** |  | 143.75d | 2013-08-26 | 2014-03-13 |  | 0d | 522.25d |  |  | 17296h | 683,808,000 |
| 24 | 1.4.1.1.1 | Ducto EMT 3/4" |  | 109d | 2013-10-11 | 2014-03-13 |  | 0d | 499.25d | finish no earlier than 2014-03-13 | Tecnico de Campo 7; Ayudante 1; Ayudante 2; Ayudante 3; Ayudante 4; Ayudante 5; Ayudante 6; Ayudante 7; Tecnico de Campo 1; Tecnico de Campo 2; Tecnico de Campo 3; Tecnico de Campo 4; Tecnico de Campo 5; Tecnico de Campo 6 | 12208h | 389,002,500 |
| 25 | 1.4.1.1.2 | Ducto EMT 1" |  | 30d | 2013-10-08 | 2013-11-19 |  | 0d | 581.25d | finish no earlier than 2013-11-19 | Ayudante 8; Tecnico de Campo 8 | 480h | 20,265,700 |
| 26 | 1.4.1.1.3 | Ducto portables tipo malla 0,3m |  | 87d | 2013-10-11 | 2014-02-11 |  | 0d | 521.25d | finish no earlier than 2014-02-11 | Ayudante 9; Ayudante 10; Tecnico de Campo 9; Tecnico de Campo 10 | 2784h | 172,550,000 |
| 27 | 1.4.1.1.4 | Canaleta plastica 15x5cms c/ visión c/accesorios |  | 98d | 2013-10-11 | 2014-02-26 |  | 0d | 510.25d | finish no earlier than 2014-02-26 | Ayudante 11; Tecnico de Campo 11 | 1568h | 86,725,500 |
| 28 | 1.4.1.1.5 | Banco de ductos de 2 ø 2" pvc |  | 11d | 2013-12-06 | 2013-12-23 |  | 0d | 557.25d | finish no earlier than 2013-12-23 | Ayudante 8; Tecnico de Campo 8 | 176h | 11,636,500 |
| 29 | 1.4.1.1.6 | Bajante en tuberia IMC de 4" en punto de conexión de MT |  | 3d | 2013-12-23 | 2013-12-26 |  | 0d | 554.25d | finish no earlier than 2013-12-26 | Ayudante 8; Tecnico de Campo 8 | 48h | 1,315,800 |
| 30 | 1.4.1.1.7 | Banco de ductos 4F de 6" para acometida en MT. |  | 2d | 2013-08-26 | 2013-08-27 |  | 0d | 664d |  | Ayudante 8; Tecnico de Campo 8 | 32h | 2,312,000 |
| 31 | 1.4.1.1.8 | TERMINACION DE CANALIZACIÓN | milestone | 0d | 2014-03-13 | 2014-03-13 |  | 0d | 500d | start no earlier than 2014-03-13 |  |  |  |

| ID | WBS | Task | Type | Duration | Start | Finish | Total slack | Free slack | Constraint | Resources | Work | Cost |
| --- | --- | --- | --- | --- | --- | --- | --- | --- | --- | --- | --- | --- |
| 32 | 1.4.1.2 | **SALIDAS** |  | 91d | 2013-10-11 | 2014-02-17 | 0d | 540.25d |  |  | 7920h | 320,257,050 |
| 33 | 1.4.1.2.1 | Salida para tomacorriente doble normal |  | 85d | 2013-10-11 | 2014-02-07 | 0d | 523.25d | finish no earlier than 2014-02-07 | Ayudante 13; Tecnico de Campo 12; Tecnico de Campo 13; Ayudante 12 | 2720h | 97,359,000 |
| 34 | 1.4.1.2.2 | Salida para tomacorriente doble regulada |  | 63d | 2013-10-25 | 2014-01-22 | 0d | 535.25d | finish no earlier than 2014-01-22 | Ayudante 14; Ayudante 15; Tecnico de Campo 14; Tecnico de Campo 15 | 2016h | 94,010,000 |
| 35 | 1.4.1.2.3 | Salida para tomacorriente doble tipo gfci |  | 3d | 2013-12-30 | 2014-01-02 | 0d | 549.25d | finish no earlier than 2014-01-02 | Ayudante 8; Tecnico de Campo 8 | 48h | 3,979,700 |
| 36 | 1.4.1.2.4 | Salida lampara fluorescente |  | 91d | 2013-10-11 | 2014-02-17 | 0d | 517.25d | finish no earlier than 2014-02-17 | Ayudante 16; Ayudante 17; Tecnico de Campo 16; Tecnico de Campo 17 | 2912h | 116,195,000 |
| 37 | 1.4.1.2.5 | Salida lampara emergencia |  | 14d | 2014-01-02 | 2014-01-22 | 0d | 535.25d | finish no earlier than 2014-01-22 | Ayudante 8; Tecnico de Campo 8 | 224h | 8,713,350 |
| 38 | 1.4.1.3 | **TABLEROS Y PROTECCIONES** |  | 27d | 2014-01-22 | 2014-02-28 | 0d | 531.25d |  |  | 1328h | 179,232,700 |
| 39 | 1.4.1.3.1 | Tablero general de distribución 1250KVA incluye transferencia. |  | 6d | 2014-01-22 | 2014-01-30 | 0d | 529.25d | finish no earlier than 2014-01-30 | Ayudante 14; Ayudante 15; Tecnico de Campo 14; Tecnico de Campo 15 | 192h | 64,339,050 |
| 40 | 1.4.1.3.2 | Tablero de distribucion Piso |  | 12d | 2014-01-30 | 2014-02-17 | 0d | 517.25d | finish no earlier than 2014-02-17 | Ayudante 14; Ayudante 15; Tecnico de Campo 14; Tecnico de Campo 15 | 384h | 70,652,000 |
| 41 | 1.4.1.3.3 | Tablero de distribucion circuitos trifasico |  | 27d | 2014-01-22 | 2014-02-28 | 0d | 508.25d | finish no earlier than 2014-02-28 | Ayudante 8; Tecnico de Campo 8 | 432h | 24,990,000 |
| 42 | 1.4.1.3.4 | Breaker enchufable |  | 11d | 2014-02-11 | 2014-02-26 | 0d | 510.25d | finish no earlier than 2014-02-26 | Ayudante 9; Tecnico de Campo 9 | 176h | 8,457,500 |
| 43 | 1.4.1.3.5 | Breaker tipo industrial regulable |  | 9d | 2014-02-07 | 2014-02-20 | 0d | 514.25d | finish no earlier than 2014-02-20 | Ayudante 13; Tecnico de Campo 13 | 144h | 10,794,150 |
| 44 | 1.4.1.4 | **SUBESTACION** |  | 45.25d | 2014-02-20 | 2014-04-25 | 0d | 492d |  |  | 2420h | 455,593,084.09 |
| 45 | 1.4.1.4.1 | Electrobarra 3200A |  | 41d | 2014-02-26 | 2014-04-24 | 0d | 469.25d | finish no earlier than 2014-04-24 | Ayudante 12; Tecnico de Campo 11; Tecnico de Campo 12; Ayudante 11; Ayudante 13; Tecnico de Campo 13; Ayudante 24 | 2296h | 329,458,609.09 |
| 46 | 1.4.1.4.2 | Caja derivadora 800-1250A EB |  | 1d | 2014-02-20 | 2014-02-21 | 0d | 513.25d | finish no earlier than 2014-02-21 | Ayudante 13; Tecnico de Campo 13 | 16h | 17,858,500 |
| 47 | 1.4.1.4.3 | Celda duplex 1250KVA |  | 1d | 2014-02-24 | 2014-02-25 | 0d | 511.25d | finish no earlier than 2014-02-25 | Ayudante 13; Tecnico de Campo 13 | 16h | 8,845,100 |
| 48 | 1.4.1.4.4 | Celda de medida 1250KVA |  | 1d | 2014-02-25 | 2014-02-26 | 0d | 510.25d | finish no earlier than 2014-02-26 | Ayudante 13; Tecnico de Campo 13 | 16h | 20,101,650 |
| 49 | 1.4.1.4.5 | Celda de proteccion 1250KVA |  | 1.75d | 2014-02-27 | 2014-02-28 | 0d | 508.25d | finish no earlier than 2014-02-28 | Ayudante 13; Tecnico de Campo 13 | 28h | 9,794,975 |
| 50 | 1.4.1.4.6 | Celda transformador 1250KVA |  | 1d | 2014-02-26 | 2014-02-26 | 0d | 510d | start no earlier than 2014-02-26 | Ayudante 14; Tecnico de Campo 14 | 16h | 6,330,800 |
| 51 | 1.4.1.4.7 | Transformador tipo seco de 1250 KVA, 11400/208-120V |  | 1d | 2014-02-27 | 2014-02-28 | 0d | 508.25d | finish no earlier than 2014-02-28 | Ayudante 14; Tecnico de Campo 14 | 16h | 51,519,350 |
| 52 | 1.4.1.4.8 | Banco de condensadores |  | 1d | 2014-03-03 | 2014-03-03 | 0d | 507d | start no earlier than 2014-03-02 | Ayudante 14; Tecnico de Campo 14 | 16h | 11,684,100 |
| 53 | 1.4.1.4.9 | TERMINACION DE INSTALACIÓN DE LA SUBESTACIÓN | milestone | 0d | 2014-04-25 | 2014-04-25 | 0d | 469d | start no earlier than 2014-04-25 |  |  |  |
| 54 | 1.4.1.5 | **UPS** |  | 86d | 2014-02-17 | 2014-06-17 | 0d | 454.25d |  |  | 1376h | 715,277,550 |
| 55 | 1.4.1.5.1 | UPS TRIFASICA DE 20 kva 208/120V |  | 10d | 2014-02-17 | 2014-03-03 | 0d | 507.25d | finish no earlier than 2014-03-03 | Ayudante 15; Tecnico de Campo 15 | 160h | 74,138,700 |
| 56 | 1.4.1.5.2 | UPS TRIFASICA DE 30 kva 208/120V |  | 76d | 2014-03-03 | 2014-06-17 | 0d | 431.25d | finish no earlier than 2014-06-17 | Ayudante 15; Tecnico de Campo 15 | 1216h | 641,138,850 |

| ID | WBS | Task | Type | Duration | Start | Finish | Predecessors | Total slack | Free slack | Constraint | Resources | Work | Cost |
| --- | --- | --- | --- | --- | --- | --- | --- | --- | --- | --- | --- | --- | --- |
| 57 | 1.4.1.6 | **ACOMETIDAS** |  | 50.25d | 2014-02-26 | 2014-05-08 |  | 0d | 483d |  |  | 7760h | 416,519,975 |
| 58 | 1.4.1.6.1 | Acometida a (a2,c3,k7) en 3x4/0+2/0+2t |  | 49d | 2014-02-26 | 2014-05-06 |  | 0d | 461.25d | finish no earlier than 2014-05-06 | Ayudante 9; Ayudante 10; Tecnico de Campo 9; Tecnico de Campo 10; Ayudante 12; Tecnico de Campo 12 | 2352h | 126,850,175 |
| 59 | 1.4.1.6.2 | Acometida a (s.agua pot.) En 3x3/0+2+4t |  | 39d | 2014-02-28 | 2014-04-24 |  | 0d | 469.25d | finish no earlier than 2014-04-24 | Ayudante 8; Ayudante 13; Ayudante 14; Tecnico de Campo 8; Tecnico de Campo 13; Tecnico de Campo 14 | 1872h | 99,883,500 |
| 60 | 1.4.1.6.3 | Acometida a (f4,h5,j6,l7) en 3x1/0+2+4t |  | 39d | 2014-03-13 | 2014-05-07 |  | 0d | 460.25d | finish no earlier than 2014-05-07 | Ayudante 1; Ayudante 2; Ayudante 3; Tecnico de Campo 1; Tecnico de Campo 2; Tecnico de Campo 3 | 1872h | 100,071,350 |
| 61 | 1.4.1.6.4 | Acometida a (m8) en 3x2+4+6t |  | 20d | 2014-03-13 | 2014-04-10 |  | 0d | 479.25d | finish no earlier than 2014-04-10 | Ayudante 4; Tecnico de Campo 4 | 320h | 16,812,150 |
| 62 | 1.4.1.6.5 | Acometida a (n8,t.reg x,f,h,j) en 3x6+8+8t |  | 17d | 2014-03-13 | 2014-04-07 |  | 0d | 482.25d | finish no earlier than 2014-04-07 | Ayudante 5; Ayudante 6; Tecnico de Campo 5; Tecnico de Campo 6 | 544h | 29,651,400 |
| 63 | 1.4.1.6.6 | Acometida en 3x4/0 awg cu-15kv-xlpe |  | 25d | 2014-03-13 | 2014-04-17 |  | 0d | 474.25d | finish no earlier than 2014-04-17 | Ayudante 7; Ayudante 16; Tecnico de Campo 7; Tecnico de Campo 16 | 800h | 43,251,400 |
| 64 | 1.4.1.6.7 | TERMINACION DE LA ACOMETIDA DEL EDIFICIO | milestone | 0d | 2014-05-08 | 2014-05-08 |  | 0d | 460d | start no earlier than 2014-05-08 |  |  |  |
| 65 | 1.4.1.7 | **SISTEMA DE PUESTA A TIERRA** |  | 166.75d | 2013-10-11 | 2014-06-02 |  | 0d | 465.25d |  |  | 560h | 36,714,900 |
| 66 | 1.4.1.7.1 | Cable de cobre desnudo no. 2/0 awg |  | 20d | 2014-05-02 | 2014-05-30 |  | 0d | 443.25d | finish no earlier than 2014-05-30 | Ayudante 8; Tecnico de Campo 8 | 320h | 24,831,900 |
| 67 | 1.4.1.7.2 | Punta de captacion de 60cm. |  | 1d | 2013-10-11 | 2013-10-11 |  | 0d | 608d | start no earlier than 2013-10-11 | Ayudante 8; Tecnico de Campo 8 | 16h | 3,044,700 |
| 68 | 1.4.1.7.3 | Varilla de cobre 5/8" x 2,4ml |  | 6d | 2013-10-11 | 2013-10-18 |  | 0d | 603d | start no earlier than 2013-10-11 | Ayudante 8; Tecnico de Campo 8 | 96h | 4,049,400 |
| 69 | 1.4.1.7.4 | Barraje de puesta a tierra TMGB |  | 1d | 2014-05-30 | 2014-06-02 |  | 0d | 442.25d | finish no earlier than 2014-05-13 | Ayudante 8; Tecnico de Campo 8 | 16h | 695,300 |
| 70 | 1.4.1.7.5 | Barraje de puesta a tierra TGB |  | 1d | 2013-12-26 | 2013-12-27 |  | 0d | 553.07d | start no earlier than 2013-10-11 | Ayudante 8; Tecnico de Campo 8 | 16h | 1,829,200 |
| 71 | 1.4.1.7.6 | Pozo de inspeccion sistema de puesta a tierra |  | 6d | 2013-10-11 | 2013-10-18 |  | 0d | 603d | start no earlier than 2013-10-11 | Ayudante 8; Tecnico de Campo 8 | 96h | 2,264,400 |
| 72 | 1.4.1.8 | **ILUMINACION** |  | 44.25d | 2014-06-13 | 2014-08-14 |  | 0d | 412d |  |  | 7736h | 580,410,600 |
| 73 | 1.4.1.8.1 | Sensor 24 vdc cobertura 360° hasta 46,5m2+pwp |  | 17d | 2014-06-19 | 2014-07-14 |  | 0d |  | finish no earlier than 2014-07-14 | Ayudante 16; Tecnico de Campo 16; Ayudante 4; Tecnico de Campo 4 | 544h | 77,879,550 |
| 74 | 1.4.1.8.2 | Panel principal interor para control de iluminacion con 8 reles 115/277vac, con tarjeta de comunicaciones, puerto dataline, tarjeta interfaces de comunicación y software. |  | 11d | 2014-06-13 | 2014-06-30 |  | 0d | 422.25d | finish no earlier than 2014-06-30 | Ayudante 5; Ayudante 17; Tecnico de Campo 5; Tecnico de Campo 17 | 352h | 11,940,800 |
| 75 | 1.4.1.8.3 | Panel interor para control de iluminacion con 8 reles 115/277vac, con tarjeta de comunicaciones y puerto dataline. |  | 25d | 2014-06-17 | 2014-07-22 |  | 0d | 406.25d | finish no earlier than 2014-07-22 | Ayudante 1; Ayudante 2; Tecnico de Campo 1; Tecnico de Campo 2 | 800h | 57,536,500 |
| 76 | 1.4.1.8.4 | Cable plenum de 2 pares |  | 19d | 2014-06-24 | 2014-07-21 |  | 0d |  | finish no earlier than 2014-07-21 | Ayudante 3; Tecnico de Campo 3 | 304h | 21,547,500 |
| 77 | 1.4.1.8.5 | Interruptor cuadruple Dataine |  | 6d | 2014-07-22 | 2014-07-30 |  | 0d | 400.25d | finish no earlier than 2014-07-30 | Ayudante 1; Ayudante 2; Tecnico de Campo 1; Tecnico de Campo 2 | 192h | 11,883,000 |
| 78 | 1.4.1.8.6 | Lámparas fluorescentes de incrustar 60x60 de 4x14w |  | 38d | 2014-06-24 | 2014-08-14 |  | 0d | 390d | start no earlier than 2014-06-24 | Ayudante 10; Ayudante 11; Ayudante 12; Tecnico de Campo 10; Tecnico de Campo 11; Tecnico de Campo 12; Ayudante 28; Ayudante 29; Ayudante 30; Tecnico de Campo 28; Tecnico de Campo 29; Tecnico de Campo 30; Ayudante 13; Ayudante 14; Tecnico de Campo 13; Tecnico de Campo 14 | 4864h | 357,159,800 |
| 79 | 1.4.1.8.7 | Bala fluorescente de incrustar de 11W |  | 1.75d | 2014-07-01 | 2014-07-02 |  | 0d | 420.25d | finish no earlier than 2014-07-02 | Ayudante 6; Ayudante 7; Tecnico de Campo 6; Tecnico de Campo 7 | 56h | 5,551,350 |
| 80 | 1.4.1.8.8 | Lampara aplique exterior de 100w |  | 1d | 2014-07-21 | 2014-07-22 | 76 | 0d | 406.25d | start no earlier than 2014-06-24 | Ayudante 3; Tecnico de Campo 3 | 16h | 800,700 |
| 81 | 1.4.1.8.9 | Lampara de emergencia |  | 19d | 2014-07-14 | 2014-08-08 | 73 | 0d | 393.25d | start no earlier than 2014-06-24 | Ayudante 15; Ayudante 16; Tecnico de Campo 15; Tecnico de Campo 16 | 608h | 36,111,400 |

| ID | WBS | Task | Type | Duration | Start | Finish | Predecessors | Total slack | Free slack | Constraint | Resources | Work | Cost |
| --- | --- | --- | --- | --- | --- | --- | --- | --- | --- | --- | --- | --- | --- |
| 82 | 1.4.2 | **SISTEMA DE TELECOMUNICACIONES** |  | 227d | 2013-10-11 | 2014-08-25 |  | 0d | 405d |  |  | 48495.8h | 3,849,551,997.17 |
| 83 | 1.4.2.1 | **CABLEADO ESTRUCTURADO** |  | 62d | 2013-10-11 | 2014-01-06 |  | 0d | 555d |  |  | 16556.6h | 984,501,556.25 |
| 84 | 1.4.2.1.1 | Enlace preconectorizado Fibra óptica OM3 MM 12 hilos 50/125 micras |  | 9d | 2013-10-11 | 2013-10-23 |  | 0d |  | start no earlier than 2013-10-11 | Tecnico de Campo 14; Ayudante 13; Ayudante 14; Tecnico de Campo 13 | 288h | 47,455,500 |
| 85 | 1.4.2.1.2 | Bandeja fibra óptica 36/72 puertos |  | 6d | 2013-10-11 | 2013-10-18 |  | 0d |  | start no earlier than 2013-10-11 | Tecnico de Campo 11; Tecnico de Campo 12; Ayudante 11; Ayudante 12 | 192h | 9,967,100 |
| 86 | 1.4.2.1.3 | Bandeja fibra óptica 144 puertos |  | 2d | 2013-10-11 | 2013-10-14 |  | 0d |  | start no earlier than 2013-10-11 | Ayudante 8; Tecnico de Campo 8 | 32h | 2,424,200 |
| 87 | 1.4.2.1.4 | Patch cord F.O Duplex LC/LC, MM 2M. |  | 10d | 2013-10-15 | 2013-10-28 | 86 | 0d | 597d | start no earlier than 2013-08-30 | Ayudante 8; Tecnico de Campo 8 | 160h | 11,067,000 |
| 88 | 1.4.2.1.5 | Panel de parcheo curvo 24 puertos 6A |  | 15d | 2013-10-11 | 2013-10-31 |  | 0d |  | start no earlier than 2013-10-11 | Ayudante 5; Ayudante 6; Ayudante 7; Tecnico de Campo 3; Tecnico de Campo 4; Tecnico de Campo 5; Tecnico de Campo 6; Tecnico de Campo 7; Ayudante 3; Ayudante 4 | 1200h | 50,129,600 |
| 89 | 1.4.2.1.6 | Organizador horizontal doble con tapa. |  | 17.93d | 2013-10-11 | 2013-11-05 |  | 0d |  | start no earlier than 2013-10-11 | Ayudante 17; Tecnico de Campo 1; Tecnico de Campo 2; Tecnico de Campo 17; Ayudante 1; Ayudante 2 | 860.6h | 40,184,706.25 |
| 90 | 1.4.2.1.7 | Salida sencilla CAT 6A |  | 41d | 2013-11-01 | 2013-12-27 | 88 | 0d | 553d | start no earlier than 2013-08-28 | Tecnico de Campo 4; Tecnico de Campo 5; Ayudante 4; Ayudante 5; Ayudante 12; Tecnico de Campo 12 | 1968h | 49,678,250 |
| 91 | 1.4.2.1.8 | Certificación cableado |  | 37d | 2013-11-05 | 2013-12-26 | 89 | 0d | 554.07d | start no earlier than 2013-08-28 | Tecnico de Campo 1; Ayudante 1; Ayudante 18; Tecnico de Campo 18; Ayudante 8; Tecnico de Campo 8 | 1776h | 17,731,000 |
| 92 | 1.4.2.1.9 | Cable UTP CAT. 6A |  | 62d | 2013-10-11 | 2014-01-06 |  | 0d |  | start no earlier than 2013-10-11 | Ayudante 19; Ayudante 20; Ayudante 21; Ayudante 22; Ayudante 23; Ayudante 24; Ayudante 25; Tecnico de Campo 19; Tecnico de Campo 20; Tecnico de Campo 21; Tecnico de Campo 22; Tecnico de Campo 23; Tecnico de Campo 24; Tecnico de Campo 25 | 6944h | 552,585,000 |
| 93 | 1.4.2.1.10 | Patch cord 7 pies UTP Cat: 6A. Azul |  | 28d | 2013-10-21 | 2013-11-27 | 85 | 0d | 575d | start no earlier than 2013-08-28 | Tecnico de Campo 11; Tecnico de Campo 12; Ayudante 11; Ayudante 12 | 896h | 48,292,750 |
| 94 | 1.4.2.1.11 | Patch cord 5 pies UTP Cat: 6A. Azul |  | 28d | 2013-10-24 | 2013-12-02 | 84 | 0d | 572d | start no earlier than 2013-08-20 | Tecnico de Campo 14; Ayudante 13; Ayudante 14; Tecnico de Campo 13 | 896h | 41,135,750 |
| 95 | 1.4.2.1.12 | Gabinete de 42 U carga admisible 420 kg |  | 28d | 2013-10-11 | 2013-11-19 |  | 0d |  | start no earlier than 2013-10-11 | Ayudante 2; Ayudante 3; Ayudante 7; Tecnico de Campo 2; Tecnico de Campo 3; Tecnico de Campo 7 | 1344h | 113,850,700 |
| 96 | 1.4.2.1.13 | TERMINACIÓN CABLEADO ESTRUCTURADO DEL EDIFICIO | milestone | 0d | 2014-01-06 | 2014-01-06 |  | 0d | 548d | start no earlier than 2014-01-06 |  |  |  |
| 97 | 1.4.2.2 | **EQUIPOS ACTIVOS** |  | 77d | 2013-11-20 | 2014-03-07 |  | 0d | 527d |  |  | 9496h | 922,802,681.83 |
| 98 | 1.4.2.2.1 | Switch Core CCTV X900 layer 3 |  | 8d | 2014-01-07 | 2014-01-16 | 92 | 0d | 539d | start no earlier than 2013-08-26 | Ayudante 20; Ayudante 21; Tecnico de Campo 20; Tecnico de Campo 21; IngenieroTecnico | 320h | 29,309,751.48 |
| 99 | 1.4.2.2.2 | Switch Core Layer 3+ Modular ipv4/ipv6. |  | 15d | 2014-01-07 | 2014-01-27 | 92 | 0d | 532d | start no earlier than 2013-11-14 | Ayudante 23; Ayudante 24; Tecnico de Campo 23; Tecnico de Campo 24; IngenieroTecnico | 600h | 198,290,188.13 |
| 100 | 1.4.2.2.3 | Switch de borde x510 48P L3 |  | 48d | 2013-11-20 | 2014-01-24 | 95 | 0d | 533d | start no earlier than 2013-08-26 | Ayudante 27; Ayudante 28; Ayudante 29; Ayudante 30; Tecnico de Campo 27; Tecnico de Campo 28; Tecnico de Campo 29; Ayudante 31; Tecnico de Campo 30; Tecnico de Campo 31; IngenieroTecnico | 4224h | 376,343,271.69 |
| 101 | 1.4.2.2.4 | Switch de borde x510 48P POE+ L3 |  | 34d | 2013-11-20 | 2014-01-06 | 95 | 0d | 547d | start no earlier than 2013-08-26 | Ayudante 32; Ayudante 33; Ayudante 34; Tecnico de Campo 32; Tecnico de Campo 33; Tecnico de Campo 34; Ingeniero de Diseño | 1904h | 145,786,742.64 |
| 102 | 1.4.2.2.5 | Modulo 10GIG SFP+SR,LF |  | 47d | 2013-11-20 | 2014-01-23 | 95 | 0d | 534d | start no earlier than 2013-08-26 | Ayudante 35; Ayudante 36; Tecnico de Campo 35; Tecnico de Campo 36 | 1504h | 97,889,547.49 |
| 103 | 1.4.2.2.6 | Modulo 500m 850nm 1000Base-SX Small Form Pluggable - Hot Swappable |  | 14d | 2013-11-20 | 2013-12-09 | 95 | 0d | 567d | start no earlier than 2013-08-26 | Ayudante 23; Ayudante 24; Tecnico de Campo 23; Tecnico de Campo 24; Ayudante 22; Tecnico de Campo 22 | 672h | 46,654,825.22 |
| 104 | 1.4.2.2.7 | Routers acceso secure vpn |  | 3d | 2013-11-20 | 2013-11-22 | 95 | 0d |  | start no earlier than 2013-08-26 | Ayudante 8; IngenieroTecnico | 48h | 6,172,668.27 |
| 105 | 1.4.2.2.8 | Firewall FG-100-BDL |  | 14d | 2013-11-25 | 2013-12-12 | 104 | 0d | 564d | start no earlier than 2013-10-11 | Ayudante 8; IngenieroTecnico | 224h | 22,355,686.91 |
| 106 | 1.4.2.2.9 | TERMINACIÓN INSTALACIÓN EQUIPOS ACTIVOS DEL EDIFICIO | milestone | 0d | 2014-03-07 | 2014-03-07 |  | 0d | 504d | start no earlier than 2014-03-07 |  |  |  |

| ID | WBS | Task | Type | Duration | Start | Finish | Predecessors | Total slack | Free slack | Constraint | Resources | Work | Cost |
| --- | --- | --- | --- | --- | --- | --- | --- | --- | --- | --- | --- | --- | --- |
| 107 | 1.4.2.3 | **TELEFONIA IP** |  | 108d | 2014-01-07 | 2014-06-06 |  | 0d | 462d |  |  | 7168h | 566,837,104.54 |
| 108 | 1.4.2.3.1 | Plataforma de voz Asterisk. |  | 39d | 2014-01-07 | 2014-02-28 |  | 0d |  | start no earlier than 2014-01-07 | Ayudante 6; IngenieroTecnico | 624h | 36,322,895.45 |
| 109 | 1.4.2.3.2 | Servidor IBM plataforma de voz. |  | 54d | 2014-03-03 | 2014-05-15 | 108 | 0d |  | start no earlier than 2014-01-07 | Ayudante 6; IngenieroTecnico | 864h | 82,644,109.09 |
| 110 | 1.4.2.3.3 | Telefonos IP |  | 38d | 2014-01-07 | 2014-02-27 |  | 0d | 509d | start no earlier than 2014-01-07 | Ayudante 7; Ayudante 9; Tecnico de Campo 7; Tecnico de Campo 9; Ayudante 18; Ayudante 19; Ayudante 20; Tecnico de Campo 18; Tecnico de Campo 19; Tecnico de Campo 20 | 3040h | 243,015,000 |
| 111 | 1.4.2.3.4 | Diademas plantronics |  | 4d | 2014-05-16 | 2014-05-21 | 109 | 0d |  | start no earlier than 2014-01-07 | Tecnico de Campo 6; Ayudante 6 | 64h | 6,944,500 |
| 112 | 1.4.2.3.5 | Telefonos IP inalambricos |  | 11d | 2014-05-22 | 2014-06-05 | 111 | 0d | 439d | start no earlier than 2014-01-07 | Tecnico de Campo 6; Ayudante 6 | 176h | 12,376,000 |
| 113 | 1.4.2.3.6 | Telefonos IP gerenciales |  | 25d | 2014-03-03 | 2014-04-04 | 108 | 0d | 483d |  | Ayudante 13; Ayudante 14; Ayudante 17; Ayudante 19; Ayudante 20; Ayudante 21; Tecnico de Campo 13; Tecnico de Campo 14; Tecnico de Campo 17; Tecnico de Campo 19; Tecnico de Campo 20; Tecnico de Campo 21 | 2400h | 185,534,600 |
| 114 | 1.4.2.3.7 | TERMINACIÓN SOLUCION DE TELEFONIA DEL EDIFICIO | milestone | 0d | 2014-06-06 | 2014-06-06 |  | 0d | 439d | start no earlier than 2014-06-06 |  |  |  |
| 115 | 1.4.2.4 | **GRABACION SALAS DE AUDIENCIAS** |  | 57d | 2014-06-06 | 2014-08-25 |  | 0d | 405d |  |  | 14683.2h | 1,328,295,154.55 |
| 116 | 1.4.2.4.1 | Servidor de torre para procesamiento de la video grabacion de las audiencias. |  | 57d | 2014-06-06 | 2014-08-25 | 108 | 0d | 382d | start no earlier than 2014-06-06 | Ayudante 19; Ayudante 20; Ayudante 21; Ayudante 22; Tecnico de Campo 19; Tecnico de Campo 20; Tecnico de Campo 21; Tecnico de Campo 22; IngenieroTecnico; Ayudante 23; Ayudante 24; Ayudante 25; Tecnico de Campo 23; Tecnico de Campo 24; Tecnico de Campo 25 | 6840h | 333,075,204.55 |
| 117 | 1.4.2.4.2 | Microfono presidente de mesa cuello de ganso. Salas de audiencia. |  | 20d | 2014-06-06 | 2014-07-03 |  | 0d |  | start no earlier than 2014-06-06 | Ayudante 13; Tecnico de Campo 13 | 320h | 57,192,250 |
| 118 | 1.4.2.4.3 | Microfono delegado de mesa tipo cuello de ganso. Salas de audiencia. |  | 26d | 2014-07-04 | 2014-08-08 | 117 | 0d | 393d | start no earlier than 2014-06-06 | Ayudante 13; Ayudante 23; Tecnico de Campo 13; Tecnico de Campo 23; Ayudante 38; Ayudante 39; Tecnico de Campo 39; Tecnico de Campo 40 | 1664h | 269,183,100 |
| 119 | 1.4.2.4.4 | Unidad central de manejo de microfonos. Salas de audiencia. |  | 56d | 2014-06-06 | 2014-08-22 |  | 0d | 406d | start no earlier than 2014-06-06 | Ayudante 25; Tecnico de Campo 25; Ayudante 40; Tecnico de Campo 40 | 1792h | 112,380,200 |
| 120 | 1.4.2.4.5 | Altavoz para montar en cielo razo, salas de audiencia. |  | 26.2d | 2014-06-06 | 2014-07-14 |  | 0d | 435.8d | start no earlier than 2014-06-06 | Ayudante 24; Tecnico de Campo 4 | 419.2h | 14,305,500 |
| 121 | 1.4.2.4.6 | Amplificador de audio digital. Salas de audiencia. |  | 47d | 2014-06-06 | 2014-08-11 |  | 0d | 392d | start no earlier than 2014-06-06 | Ayudante 11; Ayudante 12; Ayudante 14; Tecnico de Campo 11; Tecnico de Campo 12; Tecnico de Campo 14 | 2256h | 345,100,000 |
| 122 | 1.4.2.4.7 | Gabine para alojar equipos en salas de audiencia de 6 UR |  | 9d | 2014-06-06 | 2014-06-18 |  | 0d |  | start no earlier than 2014-06-06 | Ayudante 2; Ayudante 3; Ayudante 7; Tecnico de Campo 2; Tecnico de Campo 3; Tecnico de Campo 7 | 432h | 34,619,650 |
| 123 | 1.4.2.4.8 | Camara tipo PTZ. Salas de audiencia. |  | 20d | 2014-06-19 | 2014-07-16 | 122 | 0d | 410d | start no earlier than 2014-06-06 | Ayudante 2; Ayudante 3; Ayudante 7; Tecnico de Campo 2; Tecnico de Campo 3; Tecnico de Campo 7 | 960h | 162,439,250 |
| 124 | 1.4.2.5 | **SONIDO AMBIENTAL** |  | 15d | 2014-01-07 | 2014-01-27 |  | 0d | 555d |  |  | 592h | 47,115,500 |
| 125 | 1.4.2.5.1 | Amplificador DIN 2WRMS. |  | 11d | 2014-01-07 | 2014-01-21 |  | 0d | 536d | start no earlier than 2014-01-07 | Ayudante 15; Ayudante 16; Tecnico de Campo 15; Tecnico de Campo 16 | 352h | 27,455,000 |
| 126 | 1.4.2.5.2 | Cableado salidas de sonido |  | 2d | 2014-01-07 | 2014-01-08 |  | 0d |  | start no earlier than 2014-01-07 | Ayudante 20; Tecnico de Campo 20 | 32h | 1,989,000 |
| 127 | 1.4.2.5.3 | Radio MH formato DIN |  | 1d | 2014-01-09 | 2014-01-09 | 126 | 0d |  | start no earlier than 2014-01-07 | Ayudante 20; Tecnico de Campo 20 | 16h | 1,028,500 |
| 128 | 1.4.2.5.4 | Nodo Audio/Video monocanal |  | 6d | 2014-01-10 | 2014-01-17 | 127 | 0d |  | start no earlier than 2014-01-07 | Ayudante 20; Tecnico de Campo 20 | 96h | 4,097,000 |
| 129 | 1.4.2.5.5 | Altavoz para montar sobre cielo razo |  | 6d | 2014-01-20 | 2014-01-27 | 128 | 0d | 532d | start no earlier than 2014-01-07 | Ayudante 20; Tecnico de Campo 20 | 96h | 12,546,000 |
| 130 | 1.5 | SUSPENSION DEL PROYECTO | manual | 221d | 2014-08-26 | 2015-06-30 |  |  |  |  |  |  |  |

| ID | WBS | Task | Duration | Start | Finish | Predecessors | Total slack | Free slack | Constraint | Resources | Work | Cost |
| --- | --- | --- | --- | --- | --- | --- | --- | --- | --- | --- | --- | --- |
| 131 | 1.6 | **SISTEMA DE SEGURIDAD** | 151d | 2015-07-03 | 2016-01-29 |  | 0d | 31d |  |  | 19096h | 1,706,827,323.63 |
| 132 | 1.6.1 | **CCTV** | 137d | 2015-07-03 | 2016-01-11 |  | 0d | 45d |  |  | 7848h | 1,123,804,163.63 |
| 133 | 1.6.1.1 | Servidor para CCTV | 105d | 2015-07-03 | 2015-11-26 |  | 0d | 77d | start no earlier than 2015-07-03 | Ayudante 2; Tecnico de Campo 2; IngenieroTecnico | 2520h | 211,518,713.63 |
| 134 | 1.6.1.2 | Camara CCTV | 8d | 2015-07-03 | 2015-07-14 |  | 0d | 19d | start no earlier than 2015-07-03 | Ayudante 3; Tecnico de Campo 3 | 128h | 44,254,400 |
| 135 | 1.6.1.3 | Camara tipo Domo | 86d | 2015-07-03 | 2015-10-30 |  | 0d | 27d | start no earlier than 2015-07-03 | Ayudante 4; Ayudante 5; Ayudante 6; Tecnico de Campo 4; Tecnico de Campo 5; Tecnico de Campo 6 | 4128h | 583,135,700 |
| 136 | 1.6.1.4 | NSM5200-24-US (Network storage manager) | 24d | 2015-12-09 | 2016-01-11 | 135 | 0d | 45d | start no earlier than 2015-12-09 | Ayudante 4; Ayudante 5; Tecnico de Campo 4; Tecnico de Campo 5 | 768h | 105,432,300 |
| 137 | 1.6.1.5 | Monitor LCD 42", trabajo pesado | 3d | 2015-08-11 | 2015-08-13 | 134 | 0d |  | start no earlier than 2015-08-11 | Ayudante 3; Tecnico de Campo 3 | 48h | 9,484,300 |
| 138 | 1.6.1.6 | Camara Exrerior tipo PTZ | 4d | 2015-08-14 | 2015-08-19 | 137 | 0d |  | start no earlier than 2015-08-14 | Ayudante 2; Ayudante 6; Tecnico de Campo 2; Tecnico de Campo 6 | 128h | 15,725,000 |
| 139 | 1.6.1.7 | Teclado con joystick RM-NS1000 | 2d | 2015-08-14 | 2015-08-17 | 137 | 0d |  | start no earlier than 2015-08-14 | Ayudante 3; Tecnico de Campo 3 | 32h | 5,298,900 |
| 140 | 1.6.1.8 | Usb hardware key | 2d | 2015-08-18 | 2015-08-19 | 139 | 0d |  | start no earlier than 2015-08-18 | Ayudante 3; Tecnico de Campo 3 | 32h | 2,023,000 |
| 141 | 1.6.1.9 | Securos Professional - Camera stream license | 1d | 2015-08-20 | 2015-08-20 | 138 | 0d | 147d | start no earlier than 2015-08-20 | Ayudante 2; Ayudante 6; Tecnico de Campo 2; Tecnico de Campo 6 | 32h | 107,110,200 |
| 142 | 1.6.1.10 | Securos Professional Core | 1d | 2015-08-20 | 2015-08-20 | 140 | 0d |  | start no earlier than 2015-08-20 | Ayudante 3; Tecnico de Campo 3 | 16h | 38,725,150 |
| 143 | 1.6.1.11 | Securos - Remote Administrator license | 1d | 2015-08-21 | 2015-08-21 | 142 | 0d |  | start no earlier than 2015-08-21 | Ayudante 3; Tecnico de Campo 3 | 16h | 1,096,500 |
| 144 | 1.6.2 | **DETECCION DE INCENDIO** | 95d | 2015-08-24 | 2016-01-01 |  | 0d | 51d |  |  | 1520h | 104,408,560 |
| 145 | 1.6.2.1 | Panel general incendios | 26d | 2015-08-24 | 2015-09-28 | 143 | 0d |  | start no earlier than 2015-08-24 | Ayudante 3; Tecnico de Campo 3 | 416h | 25,250,950 |
| 146 | 1.6.2.2 | Detector de humo fotoeléctrico | 31d | 2015-09-29 | 2015-11-10 | 145 | 0d |  | start no earlier than 2015-09-29 | Ayudante 3; Tecnico de Campo 3 | 496h | 27,412,500 |
| 147 | 1.6.2.3 | Detector de Humo en ductos | 5d | 2015-11-11 | 2015-11-17 | 146 | 0d |  | start no earlier than 2015-11-11 | Ayudante 3; Tecnico de Campo 3 | 80h | 8,593,500 |
| 148 | 1.6.2.4 | Estación manual | 5d | 2015-11-18 | 2015-11-24 | 147 | 0d |  | start no earlier than 2015-11-18 | Ayudante 3; Tecnico de Campo 3 | 80h | 6,313,800 |
| 149 | 1.6.2.5 | Parlante / estrobo | 5d | 2015-11-25 | 2015-12-01 | 148 | 0d |  | start no earlier than 2015-11-25 | Ayudante 3; Tecnico de Campo 3 | 80h | 5,343,950 |
| 150 | 1.6.2.6 | Estacion telefonica | 3d | 2015-12-02 | 2015-12-04 | 149 | 0d |  | start no earlier than 2015-12-02 | Ayudante 3; Tecnico de Campo 3 | 48h | 4,369,000 |
| 151 | 1.6.2.7 | Sirenas tipo Industrial | 1d | 2015-12-07 | 2015-12-07 | 150 | 0d |  | start no earlier than 2015-12-07 | Ayudante 3; Tecnico de Campo 3 | 16h | 1,371,050 |
| 152 | 1.6.2.8 | Modulos Monitores del sistema | 1d | 2015-12-08 | 2015-12-08 | 151 | 0d |  | start no earlier than 2015-12-08 | Ayudante 3; Tecnico de Campo 3 | 16h | 549,950 |
| 153 | 1.6.2.9 | Modulos de Control | 2d | 2015-12-09 | 2015-12-10 | 152 | 0d |  | start no earlier than 2015-12-09 | Ayudante 3; Tecnico de Campo 3 | 32h | 1,364,250 |
| 154 | 1.6.2.10 | Estación Telefónica remota | 6d | 2015-12-11 | 2015-12-18 | 153 | 0d |  | start no earlier than 2015-12-11 | Ayudante 3; Tecnico de Campo 3 | 96h | 7,452,800 |
| 155 | 1.6.2.11 | Cableado sensores Cu FLPR 2x18awg | 10d | 2015-12-21 | 2016-01-01 | 154 | 0d | 51d | start no earlier than 2015-12-21 | Ayudante 3; Tecnico de Campo 3 | 160h | 16,386,810 |

| ID | WBS | Task | Type | Duration | Start | Finish | Predecessors | Total slack | Free slack | Constraint | Resources | Work | Cost |
| --- | --- | --- | --- | --- | --- | --- | --- | --- | --- | --- | --- | --- | --- |
| 156 | 1.6.3 | **EXTINCION SECA** |  | 60d | 2015-11-09 | 2016-01-29 |  | 0d | 31d |  |  | 6000h | 311,704,350 |
| 157 | 1.6.3.1 | Sistema de extincion seca Datacenter |  | 42d | 2015-11-09 | 2016-01-05 |  | 0d | 49d | start no earlier than 2015-11-09 | Ayudante 8; Ayudante 9; Tecnico de Campo 7; Tecnico de Campo 8; Tecnico de Campo 9; Ayudante 7 | 2016h | 102,952,850 |
| 158 | 1.6.3.2 | Sistema de extincion seca cuartos tecnicos |  | 60d | 2015-11-09 | 2016-01-29 |  | 0d | 31d | start no earlier than 2015-11-09 | Ayudante 5; Ayudante 6; Tecnico de Campo 4; Tecnico de Campo 5; Tecnico de Campo 6; Ayudante 4; Ayudante 7; Tecnico de Campo 7 | 3840h | 197,120,100 |
| 159 | 1.6.3.3 | Modulo siga-rel |  | 5d | 2015-11-09 | 2015-11-13 |  | 0d |  | start no earlier than 2015-11-09 | Tecnico de Campo 1; Ayudante 1 | 80h | 6,849,300 |
| 160 | 1.6.3.4 | Estacion de descarga manual |  | 1d | 2015-11-16 | 2015-11-16 | 159 | 0d |  | start no earlier than 2015-11-16 | Tecnico de Campo 1; Ayudante 1 | 16h | 1,216,350 |
| 161 | 1.6.3.5 | Estacion de aborto |  | 1d | 2015-11-17 | 2015-11-17 | 160 | 0d |  | start no earlier than 2015-11-17 | Tecnico de Campo 1; Ayudante 1 | 16h | 1,168,750 |
| 162 | 1.6.3.6 | Interruptor de desconexion de solenoide + relevo |  | 2d | 2015-11-18 | 2015-11-19 | 161 | 0d | 82d | start no earlier than 2015-11-18 | Tecnico de Campo 1; Ayudante 1 | 32h | 2,397,000 |
| 163 | 1.6.4 | **SISTEMA CONTROL DE ACCESO** |  | 80d | 2015-09-11 | 2015-12-31 |  | 0d | 52d |  |  | 3728h | 166,910,250 |
| 164 | 1.6.4.1 | Equipo de Control de Acceso y Seguridad para 8 jegos de lectoras de proximidad |  | 50d | 2015-09-11 | 2015-11-19 |  | 0d |  | start no earlier than 2015-09-11 | Ayudante 11; Ayudante 12; Ayudante 13; Ayudante 14; Tecnico de Campo 11; Tecnico de Campo 12; Tecnico de Campo 13; Tecnico de Campo 14 | 3200h | 117,112,150 |
| 165 | 1.6.4.2 | Lectora de proximidad |  | 4d | 2015-11-20 | 2015-11-25 | 164 | 0d |  | start no earlier than 2015-11-20 | Ayudante 11; Tecnico de Campo 11 | 64h | 10,497,500 |
| 166 | 1.6.4.3 | Trajetas lectora de proximidad |  | 13d | 2015-11-26 | 2015-12-14 | 165 | 0d |  | start no earlier than 2015-11-26 | Ayudante 11; Tecnico de Campo 11 | 208h | 6,757,500 |
| 167 | 1.6.4.4 | Boton pulsador |  | 5d | 2015-12-15 | 2015-12-21 | 166 | 0d |  | start no earlier than 2015-12-15 | Ayudante 11; Tecnico de Campo 11 | 80h | 4,992,050 |
| 168 | 1.6.4.5 | Electroiman |  | 7d | 2015-12-22 | 2015-12-30 | 167 | 0d |  | start no earlier than 2015-12-22 | Ayudante 11; Tecnico de Campo 11 | 112h | 24,006,550 |
| 169 | 1.6.4.6 | Cableado perifericos de entrada UTP cat. 5E |  | 1d | 2015-12-31 | 2015-12-31 | 168 | 0d | 52d | start no earlier than 2015-12-31 | Ayudante 11; Ayudante 12; Ayudante 13; Ayudante 14; Tecnico de Campo 11; Tecnico de Campo 12; Tecnico de Campo 13; Tecnico de Campo 14 | 64h | 3,544,500 |
| 170 | 1.6.5 | TERMINACION IMPLEMENTACION INGENIERÍA INTERDISCIPLINARIA | milestone | 0d | 2016-01-29 | 2016-01-29 |  | 0d | 32d | start no earlier than 2016-01-29 |  |  |  |
| 171 | 1.7 | **TRAMITES** |  | 28d | 2016-01-04 | 2016-02-10 |  | 0d | 23d |  |  | 672h | 649,090.91 |
| 172 | 1.7.1 | Tramites ante la empresa de energia local (codensa) |  | 16d | 2016-01-04 | 2016-01-25 |  | 0d |  | start no earlier than 2016-01-04 | IngenieroTecnico; Dibujante Tecnico 1; Dibujante Tecnico 2 | 384h | 370,909.09 |
| 173 | 1.7.2 | Tramites RETIE |  | 4d | 2016-01-26 | 2016-01-29 | 172 | 0d |  | start no earlier than 2016-01-26 | IngenieroTecnico; Dibujante Tecnico 1; Dibujante Tecnico 2 | 96h | 92,727.27 |
| 174 | 1.7.3 | Tramites RETILAP |  | 8d | 2016-02-01 | 2016-02-10 | 173 | 0d | 23d | start no earlier than 2016-02-01 | IngenieroTecnico; Dibujante Tecnico 1; Dibujante Tecnico 2 | 192h | 185,454.55 |
| 175 | 1.8 | **AUDITORÍA INTERNA DEL PROYECTO** |  | 29d | 2016-01-01 | 2016-02-10 |  | 0d | 5d |  |  | 416h | 286,782,107.74 |
| 176 | 1.8.1 | Comprobación sistema electrico |  | 3d | 2016-01-01 | 2016-01-05 |  | 0d |  | start no earlier than 2016-01-01 | Encargado de Obra; Residente de Obra | 48h | 47,864,663.79 |
| 177 | 1.8.2 | Comprobación sistema telecomunicaciones |  | 7d | 2016-01-06 | 2016-01-14 | 176 | 0d |  | start no earlier than 2016-01-06 | Encargado de Obra; Residente de Obra | 112h | 47,783,488.79 |
| 178 | 1.8.3 | Comprobación sistema seguridad |  | 7d | 2016-01-15 | 2016-01-25 | 177 | 0d |  | start no earlier than 2016-01-15 | Encargado de Obra; Residente de Obra | 112h | 47,783,488.79 |
| 179 | 1.8.4 | Levantamiento de protocolos de prueba |  | 3d | 2016-01-26 | 2016-01-28 | 178 | 0d |  | start no earlier than 2016-01-26 | Encargado de Obra; Residente de Obra | 48h | 47,783,488.79 |
| 180 | 1.8.5 | Desarrollo de protocolos de prueba |  | 4d | 2016-01-29 | 2016-02-03 | 179 | 0d |  | start no earlier than 2016-01-29 | Encargado de Obra; Residente de Obra | 64h | 47,783,488.79 |
| 181 | 1.8.6 | Elaborar formatos de actas de entrega parciales por subsistemas |  | 5d | 2016-02-04 | 2016-02-10 | 180 | 0d |  | start no earlier than 2016-02-04 | Encargado de Obra; Residente de Obra | 80h | 47,783,488.79 |

| ID | WBS | Task | Type | Duration | Start | Finish | Predecessors | Total slack | Free slack | Constraint | Resources | Work | Cost |
| --- | --- | --- | --- | --- | --- | --- | --- | --- | --- | --- | --- | --- | --- |
| 182 | 1.9 | **ENTREGA Y CIERRE DE IMPLEMENTACIÓN** |  | 20d | 2016-02-11 | 2016-03-10 |  | 0d | 3d |  |  | 288h | 3,964,090.91 |
| 183 | 1.9.1 | Verificación del Alcance de los Entregables |  | 10d | 2016-02-11 | 2016-02-24 | 181 | 0d |  | start no earlier than 2016-02-11 | Encargado de Obra; Residente de Obra | 160h | 2,202,272.73 |
| 184 | 1.9.2 | Cierre Documental |  | 7d | 2016-02-25 | 2016-03-04 | 183 | 0d |  | start no earlier than 2016-02-25 | Encargado de Obra; Residente de Obra | 112h | 1,541,590.91 |
| 185 | 1.9.3 | Acta de Entrega del Proyecto |  | 1d | 2016-03-07 | 2016-03-07 | 184 | 0d | 5d | start no earlier than 2016-03-07 | Encargado de Obra; Residente de Obra | 16h | 220,227.27 |
| 186 | 1.9.4 | FIN EJECUCION DEL PROYECTO | milestone | 0d | 2016-03-14 | 2016-03-14 |  | 0d | 3d | start no earlier than 2016-03-14 |  |  |  |
